# LN2SUPA

Schedule from MS Project, 2005-05-03 to 2005-12-21.

## Calendars

- Standard: Mon-Fri 08:00-12:00, 13:00-17:00; Sat-Sun off.

## Schedule

| ID | WBS | Task | Duration | Start | Finish | Predecessors | Baseline start | Baseline finish | Baseline duration | Total slack | Free slack | Constraint |
| --- | --- | --- | --- | --- | --- | --- | --- | --- | --- | --- | --- | --- |
| 2 | 1 | **Attivita' preliminari** | 69d | 2005-05-03 | 2005-08-05 |  | 2004-07-01 | 2004-09-15 | 55d | 19d |  |  |
| 3 | 1.1 | Emissione disegni di officina e lista materiali | 2w | 2005-05-03 | 2005-05-16 |  |  |  |  | 117d | 0d | start no earlier than 2005-05-03 |
| 4 | 1.2 | Approvvigionamento materiali | 12w | 2005-05-16 | 2005-08-05 |  |  |  |  | 10d |  | start no earlier than 2005-05-16 |
| 5 | 1.3 | Emissione PFC e QPS | 1w | 2005-05-17 | 2005-05-23 | 3 |  |  |  | 117d | 0d |  |
| 6 | 1.4 | Qualifiche procedimenti | 8w | 2005-05-24 | 2005-07-18 | 5 |  |  |  | 117d |  |  |
| 8 | 2 | **Fabbricazione** | 108d | 2005-07-25 | 2005-12-21 |  | 2004-09-27 | 2004-11-16 | 37d | 0d |  |  |
| 9 | 2.1 | Assiemaggio e saldatura camera a vuoto | 3w | 2005-07-25 | 2005-08-12 | 4SS+8w | 2004-09-29 | 2004-10-05 | 1w | 0d |  | start no earlier than 2005-07-25 |
| 10 | 2.2 | Assiemaggio e saldatura camera criogenica | 4w | 2005-08-15 | 2005-09-09 | 9 | 2004-09-30 | 2004-10-01 | 2d | 0d |  |  |
| 11 | 2.3 | Lavorazione meccanica camera a vuoto | 2w | 2005-08-22 | 2005-09-02 | 9FS+1w | 2004-09-29 | 2004-09-29 | 1d | 78d |  |  |
| 12 | 2.4 | Lavorazione meccanica della camera criogenica | 2w | 2005-09-19 | 2005-09-30 | 10FS+1w | 2004-10-06 | 2004-10-06 | 1d | 0d |  |  |
| 13 | 2.5 | Decapaggio e passivazione | 1w | 2005-10-03 | 2005-10-07 | 12 |  |  |  | 0d |  |  |
| 14 | 2.6 | Elettrolucidatura della camera a vuoto | 2w | 2005-10-10 | 2005-10-21 | 13 |  |  |  | 0d |  |  |
| 15 | 2.7 | Montaggio e sadatura delle tubazioni e dei soffietti | 2w | 2005-10-24 | 2005-11-04 | 14 |  |  |  | 0d |  |  |
| 16 | 2.8 | Montaggio ella strumentazione | 1w | 2005-11-07 | 2005-11-11 | 15 |  |  |  | 0d |  |  |
| 17 | 2.9 | Applicazione della superisolazione | 1w | 2005-11-14 | 2005-11-18 | 16 | 2004-10-07 | 2004-10-12 | 4d | 0d |  |  |
| 18 | 2.10 | Assiemaggio e chiusura del criostato | 1w | 2005-11-21 | 2005-11-25 | 17 | 2004-10-04 | 2004-10-04 | 1d | 0d |  |  |
| 19 | 2.11 | Controllo dimensionale | 3d | 2005-11-28 | 2005-11-30 | 18 |  |  |  | 0d |  |  |
| 20 | 2.12 | Prova idraulica | 3d | 2005-12-01 | 2005-12-05 | 19 | 2004-10-15 | 2004-10-19 | 3d | 0d |  | start no earlier than 2004-10-20 |
| 21 | 2.13 | Assciugatura | 3d | 2005-12-06 | 2005-12-08 | 20 |  |  |  | 0d |  |  |
| 22 | 2.14 | Prova a vuoto | 3d | 2005-12-09 | 2005-12-13 | 21 |  |  |  | 0d |  |  |
| 23 | 2.15 | Prova ad He | 4d | 2005-12-14 | 2005-12-19 | 22 | 2004-10-20 | 2004-10-25 | 4d | 0d |  | start no earlier than 2004-10-11 |
| 24 | 2.16 | Spedizione | 2d | 2005-12-20 | 2005-12-21 | 23 | 2004-11-16 | 2004-11-16 | 1d | 0d |  |  |
